# ESP_planning2007_v3

Schedule from MS Project, 2006-08-02 to 2008-03-24, A marks actual dates.
MBARI

## Calendars

- Standard: Mon-Fri 08:00-12:00, 13:00-17:00; Sat-Sun off.

## Resources

| Resource |
| --- |
| Software |
| SE |
| ME |
| ME_Tech |
| Team |
| EE |
| EE_Tech |
| Scott |
| Gene |
| Mark Brown |
| Brent |
| Roman |
| Kevin |
| Kevni |
| Conway |
| Mechatronic |
| Science |

## Schedule

| ID | WBS | Task | Type | Duration | Start | Finish | Predecessors | Total slack | Free slack | Constraint | Resources | Work |
| --- | --- | --- | --- | --- | --- | --- | --- | --- | --- | --- | --- | --- |
| 1 | 1 | **Deep ESP/NASA ASTEP** |  | 384d? | 2006-08-02 | 2008-01-21 |  | 45d |  |  |  | 6308h |
| 2 | 1.1 | **Complete Control S/W** |  | 63d | 2006-08-02 | 2006-10-27 |  | 348d |  |  |  | 504h |
| 3 | 1.1.1 | Operational modes verified |  | 20d | 2006-08-02 | 2006-08-29 |  | 81d | 0d |  | SE | 160h |
| 4 | 1.1.2 | S/W states implemented |  | 20d | 2006-08-30 | 2006-09-26 | 3 | 81d | 0d |  | SE | 160h |
| 5 | 1.1.3 | DWSM Protocols |  | 5d | 2006-09-27 | 2006-10-03 | 4 | 28d | 0d |  | SE | 40h |
| 6 | 1.1.4 | DWSM Software test plan |  | 1d | 2006-10-04 | 2006-10-04 | 5 | 351d | 0d |  | SE | 8h |
| 7 | 1.1.5 | DWSM Software tests |  | 5d | 2006-10-05 | 2006-10-11 | 6 | 351d | 0d |  | SE | 40h |
| 8 | 1.1.6 | Analyze at different pressures |  | 5d | 2006-10-12 | 2006-10-18 | 7 | 351d | 0d |  | SE | 40h |
| 9 | 1.1.7 | Help with cold room tests |  | 2d | 2006-10-19 | 2006-10-20 | 8 | 351d | 0d |  | EE | 16h |
| 10 | 1.1.8 | Analyze at different temperatures |  | 5d | 2006-10-23 | 2006-10-27 | 9 | 351d | 0d |  | SE | 40h |
| 11 | 1.2 | **Core redesign** |  | 45d | 2006-08-07 | 2006-10-06 |  | 381d |  |  |  | 360h |
| 12 | 1.2.1 | Waste container & struts redesign |  | 5d | 2006-08-07 | 2006-08-11 |  | 359d | 0d | start no earlier than 2006-08-07 | ME_Tech | 40h |
| 13 | 1.2.2 | Reagent Storage design |  | 10d | 2006-09-11 | 2006-09-22 |  | 359d | 0d | start no earlier than 2006-09-11 | ME | 80h |
| 14 | 1.2.3 | Waste container fab |  | 20d | 2006-08-14 | 2006-09-08 | 12 | 401d |  |  | ME_Tech | 160h |
| 15 | 1.2.4 | Reagent storage fab. |  | 10d | 2006-09-25 | 2006-10-06 | 13 | 359d | 0d |  | ME_Tech | 80h |
| 16 | 1.3 | **Deployment Design** |  | 22d | 2006-10-09 | 2006-11-07 |  | 359d |  |  |  | 136h |
| 17 | 1.3.1 | Design sled interface |  | 5d | 2006-10-09 | 2006-10-13 | 15 | 359d | 0d |  |  |  |
| 18 | 1.3.2 | Sled interface fab |  | 10d | 2006-10-16 | 2006-10-27 | 17 | 359d | 0d |  | ME | 80h |
| 19 | 1.3.3 | Re-plumb |  | 2d | 2006-10-30 | 2006-10-31 | 18 | 359d | 0d |  | ME_Tech | 16h |
| 20 | 1.3.4 | Readiness review preparation |  | 5d | 2006-11-01 | 2006-11-07 | 19 | 359d |  |  | Team | 40h |
| 21 | 1.3.5 | Readiness Review | milestone | 0d | 2006-10-27 | 2006-10-27 | 10 | 366d |  |  | Team |  |
| 22 | 1.4 | **Tests and Integration** |  | 74d | 2006-10-19 | 2007-01-31 |  | 299d |  |  |  | 224h |
| 23 | 1.4.1 | Plumb straight pipe can |  | 2d | 2006-10-19 | 2006-10-20 | 8 | 371d |  |  | ME_Tech | 16h |
| 24 | 1.4.2 | Bench test straight pipe |  | 5d | 2006-10-30 | 2006-11-03 | 10 | 351d | 0d |  | SE | 40h |
| 25 | 1.4.3 | Trial ASTEP canning |  | 1d | 2006-11-06 | 2006-11-06 | 24 | 348d | 0d |  | EE | 8h |
| 26 | 1.4.4 | All cables & connectors installed |  | 1d | 2006-10-19 | 2006-10-19 | 8 | 372d |  |  | EE | 8h |
| 27 | 1.4.5 | Cold test |  | 1d | 2006-11-07 | 2006-11-07 | 25 | 348d | 0d |  | EE | 8h |
| 28 | 1.4.6 | Tank test |  | 1d | 2006-11-08 | 2006-11-08 | 27 | 348d | 0d |  | EE | 8h |
| 29 | 1.4.7 | Bench test with instrument |  | 5d | 2006-11-09 | 2006-11-15 | 28 | 351d | 13d |  | SE | 40h |
| 30 | 1.4.8 | Bench test with instrument |  | 10d | 2006-11-09 | 2006-11-22 | 28 | 348d | 2d |  | EE | 80h |
| 31 | 1.4.9 | ROV straight pipe test | milestone | 0d | 2006-11-27 | 2006-11-27 | 30 | 346d |  | start no earlier than 2006-11-27 | Team |  |
| 32 | 1.4.10 | ROV with instrument | milestone | 0d | 2006-12-05 | 2006-12-05 | 29 | 338d | 0d | start no earlier than 2006-12-05 | Team |  |
| 33 | 1.4.11 | Lessons learned from 1K |  | 2d | 2006-12-05 | 2006-12-06 | 32 | 338d |  |  | Team | 16h |
| 34 | 1.4.12 | 1K Depth Profiling | milestone | 0d | 2007-01-31 | 2007-01-31 |  | 262d | 0d | start no earlier than 2007-01-31 | Team |  |

| ID | WBS | Task | Type | Duration | Start | Finish | Predecessors | Total slack | Free slack | Constraint | Resources | Work |
| --- | --- | --- | --- | --- | --- | --- | --- | --- | --- | --- | --- | --- |
| 35 | 1.5 | **3K Redesign** |  | 150d | 2007-01-08 | 2007-08-03 |  | 166d |  | start no earlier than 2007-01-08 |  | 1816h |
| 36 | 1.5.1 | Design trades for 3K housings |  | 5d | 2007-01-08 | 2007-01-12 |  | 136d | 0d | start no earlier than 2007-01-08 | ME | 40h |
| 37 | 1.5.2 | Design deep housing |  | 15d | 2007-01-15 | 2007-02-02 | 36 | 136d | 0d |  | ME | 120h |
| 38 | 1.5.3 | Piston redesign for 3K actuation |  | 15d | 2007-02-05 | 2007-02-23 | 37 | 136d | 0d |  | ME | 120h |
| 39 | 1.5.4 | Tiburon power interface |  | 30d | 2007-02-26 | 2007-04-06 | 38 | 166d | 0d |  | EE | 240h |
| 40 | 1.5.5 | MARS interface design |  | 5d | 2007-04-09 | 2007-04-13 | 39 | 166d | 0d |  | EE | 40h |
| 41 | 1.5.6 | CDR Preparation |  | 5d | 2007-04-16 | 2007-04-20 | 40 | 166d | 0d |  | ME; EE | 80h |
| 42 | 1.5.7 | CDR | milestone | 0d | 2007-04-20 | 2007-04-20 | 41 | 166d | 0d |  | EE; ME |  |
| 43 | 1.5.8 | MARS interface fab |  | 15d | 2007-04-23 | 2007-05-11 | 42 | 166d | 0d |  | EE | 120h |
| 44 | 1.5.9 | Integrate new Elmo Controllers |  | 10d | 2007-05-14 | 2007-05-25 | 43 | 166d | 0d |  | EE | 80h |
| 45 | 1.5.10 | Modify s/w for new elmos |  | 20d | 2007-01-31 | 2007-02-27 | 34 | 262d | 0d |  | SE | 160h |
| 46 | 1.5.11 | Modify DWSM Protocols |  | 10d | 2007-02-28 | 2007-03-13 | 45 | 262d | 0d |  | SE | 80h |
| 47 | 1.5.12 | Test Plan |  | 2d | 2007-03-14 | 2007-03-15 | 46 | 262d | 0d |  | SE | 16h |
| 48 | 1.5.13 | Integrate contextual sensors |  | 5d | 2007-03-16 | 2007-03-22 | 47 | 262d |  |  | SE | 40h |
| 49 | 1.5.14 | Integrate LLNL PCR unit |  | 20d | 2007-05-28 | 2007-06-22 | 44 | 166d | 0d |  | Team | 160h |
| 50 | 1.5.15 | **Elevator** |  | 30d | 2007-06-25 | 2007-08-03 | 49 | 166d |  |  |  | 240h |
| 51 | 1.5.15.1 | Design Elevator |  | 15d | 2007-06-25 | 2007-07-13 |  | 166d | 0d |  | Conway | 120h |
| 52 | 1.5.15.2 | Elevator Fab. |  | 15d | 2007-07-16 | 2007-08-03 | 51 | 166d |  |  | ME_Tech | 120h |
| 53 | 1.5.16 | **Extend Carousel** |  | 35d | 2007-01-08 | 2007-02-23 |  | 281d |  |  |  | 280h |
| 54 | 1.5.16.1 | Redesign structs |  | 2d | 2007-01-08 | 2007-01-09 |  | 281d | 0d |  | ME_Tech | 16h |
| 55 | 1.5.16.2 | Redesign Carousel |  | 10d | 2007-01-10 | 2007-01-23 | 54 | 281d | 0d |  | ME_Tech | 80h |
| 56 | 1.5.16.3 | Fab. Carousel |  | 20d | 2007-01-24 | 2007-02-20 | 55 | 281d | 0d |  | ME_Tech | 160h |
| 57 | 1.5.16.4 | Fab. Struts |  | 3d | 2007-02-21 | 2007-02-23 | 56 | 281d |  |  | ME_Tech | 24h |
| 60 | 1.6 | **LLNL Fluidic Block** |  | 384d? | 2006-08-02 | 2008-01-21 |  | 45d |  |  |  | 3268h |
| 61 | 1.6.1 | **Benchtop Fluid Concept** |  | 65d | 2006-10-02 | 2006-12-29 |  | 45d |  |  |  | 700h |
| 62 | 1.6.1.1 | Ready electronics |  | 20d | 2006-10-02 | 2006-10-27 |  | 45d | 0d | start no earlier than 2006-10-02 | EE | 160h |
| 63 | 1.6.1.2 | Assemble temporary setup |  | 15d | 2006-10-30 | 2006-11-17 | 62 | 351d |  |  | ME | 120h |
| 64 | 1.6.1.3 | Assemble temporary setup |  | 10d | 2006-10-30 | 2006-11-10 | 62 | 45d | 0d |  | EE | 80h |
| 65 | 1.6.1.4 | Develop control s/w |  | 10d | 2006-11-13 | 2006-11-24 | 64 | 45d | 0d |  | SE | 80h |
| 66 | 1.6.1.5 | Test slug and valve control |  | 15d | 2006-11-27 | 2006-12-15 | 65 | 45d | 0d |  | SE; EE [50%] | 180h |
| 67 | 1.6.1.6 | Concept design document |  | 3d | 2006-12-18 | 2006-12-20 | 66 | 45d | 0d |  | ME | 24h |
| 68 | 1.6.1.7 | PDR Preparation |  | 7d | 2006-12-21 | 2006-12-29 | 67 | 45d | 0d |  | ME | 56h |
| 69 | 1.6.1.8 | PDR | milestone | 0d | 2006-12-29 | 2006-12-29 | 68 | 45d | 0d |  | Team |  |

| ID | WBS | Task | Type | Duration | Start | Finish | Predecessors | Total slack | Free slack | Resources | Work |
| --- | --- | --- | --- | --- | --- | --- | --- | --- | --- | --- | --- |
| 70 | 1.6.2 | **Plug in and benchtop design** |  | 48d? | 2007-01-01 | 2007-03-07 |  | 45d |  |  | 384h |
| 71 | 1.6.2.1 | Mechanical design |  | 14d | 2007-01-01 | 2007-01-18 | 69 | 45d | 0d | ME | 112h |
| 72 | 1.6.2.2 | Electrical Design |  | 14d | 2007-01-19 | 2007-02-07 | 71 | 45d | 0d | EE | 112h |
| 73 | 1.6.2.3 | Software Design |  | 14d | 2007-02-08 | 2007-02-27 | 72 | 45d | 0d | SE | 112h |
| 74 | 1.6.2.4 | Complete design doc |  | 5d | 2007-02-28 | 2007-03-06 | 73 | 45d | 0d | Team | 40h |
| 75 | 1.6.2.5 | CDR Preparation |  | 1d? | 2007-03-07 | 2007-03-07 | 74 | 45d | 0d | Team | 8h |
| 76 | 1.6.2.6 | CDR | milestone | 0d | 2007-03-07 | 2007-03-07 | 75 | 45d | 0d | Team |  |
| 77 | 1.6.3 | **Plug-in benchtop Fabrication** |  | 133d | 2007-03-08 | 2007-09-10 |  | 45d |  |  | 1064h |
| 78 | 1.6.3.1 | Procure fluidic parts |  | 21d | 2007-03-08 | 2007-04-05 | 76 | 45d | 0d | Kevin | 168h |
| 79 | 1.6.3.2 | fabrication of assembly |  | 21d | 2007-04-06 | 2007-05-04 | 78 | 45d | 0d | ME_Tech | 168h |
| 80 | 1.6.3.3 | Electrical assembly |  | 21d | 2007-05-07 | 2007-06-04 | 79 | 45d | 0d | EE_Tech | 168h |
| 81 | 1.6.3.4 | S/W development |  | 30d | 2007-06-05 | 2007-07-16 | 80 | 45d | 0d | SE | 240h |
| 82 | 1.6.3.5 | S/W Testing |  | 30d | 2007-07-17 | 2007-08-27 | 81 | 45d | 0d | SE | 240h |
| 83 | 1.6.3.6 | Calibration & Testing |  | 10d | 2007-08-28 | 2007-09-10 | 82 | 45d | 0d | Team | 80h |
| 84 | 1.6.4 | **Assay Development** |  | 10d? | 2006-08-02 | 2006-08-15 |  | 419d |  |  | 80h |
| 85 | 1.6.4.1 | SH Assay Development & Testing |  | 1d? | 2006-08-02 | 2006-08-02 |  | 419d | 0d | Science | 8h |
| 86 | 1.6.4.2 | PCR Assay Development & Testing |  | 1d? | 2006-08-03 | 2006-08-03 | 85 | 419d | 0d | Science | 8h |
| 87 | 1.6.4.3 | Probe validation and calibration |  | 1d? | 2006-08-04 | 2006-08-04 | 86 | 419d | 0d | Science | 8h |
| 88 | 1.6.4.4 | Identify possible positive control |  | 1d? | 2006-08-07 | 2006-08-07 | 87 | 419d | 0d | Science | 8h |
| 89 | 1.6.4.5 | Reagent stability test |  | 1d? | 2006-08-08 | 2006-08-08 | 88 | 419d | 0d | Science | 8h |
| 90 | 1.6.4.6 | Bench comparison w/ realistic sample volume |  | 1d? | 2006-08-09 | 2006-08-09 | 89 | 419d | 0d | Science | 8h |
| 91 | 1.6.4.7 | Run hybrid on bench, test with cold |  | 1d? | 2006-08-10 | 2006-08-10 | 90 | 419d | 0d | Science | 8h |
| 92 | 1.6.4.8 | **Science Test** |  | 3d? | 2006-08-11 | 2006-08-15 |  | 419d |  |  | 24h |
| 93 | 1.6.4.8.1 | ESP lab test (existing unit) |  | 1d? | 2006-08-11 | 2006-08-11 | 91 | 419d | 0d | Science | 8h |
| 94 | 1.6.4.8.2 | ESP Lab test (ASTEP dedicated unit) |  | 1d? | 2006-08-14 | 2006-08-14 | 93 | 419d | 0d | Science | 8h |
| 95 | 1.6.4.8.3 | Presentation and publications |  | 1d? | 2006-08-15 | 2006-08-15 | 94 | 419d |  | Science | 8h |

| ID | WBS | Task | Type | Duration | Start | Finish | Predecessors | Total slack | Free slack | Constraint | Resources | Work |
| --- | --- | --- | --- | --- | --- | --- | --- | --- | --- | --- | --- | --- |
| 96 | 1.6.5 | **Ship based unit** |  | 95d | 2007-09-11 | 2008-01-21 |  | 45d |  |  |  | 1040h |
| 97 | 1.6.5.1 | Procurement |  | 30d | 2007-09-11 | 2007-10-22 | 83 | 45d | 0d |  | Kevin | 240h |
| 98 | 1.6.5.2 | Mechanical fab. |  | 10d | 2007-10-23 | 2007-11-05 | 97 | 100d |  |  | ME_Tech | 80h |
| 99 | 1.6.5.3 | Electrical Fab. |  | 10d | 2007-10-23 | 2007-11-05 | 97 | 100d |  |  | EE_Tech | 80h |
| 100 | 1.6.5.4 | S/W refinement |  | 20d | 2007-10-23 | 2007-11-19 | 97 | 45d | 0d |  | SE | 160h |
| 101 | 1.6.5.5 | GUI S/W integration |  | 15d | 2007-11-20 | 2007-12-10 | 100 | 75d |  |  | SE | 120h |
| 102 | 1.6.5.6 | Testing |  | 30d | 2007-11-20 | 2007-12-31 | 100 | 45d | 0d |  | SE | 240h |
| 103 | 1.6.5.7 | Protocol Development |  | 15d | 2008-01-01 | 2008-01-21 | 102 | 45d |  |  | SE | 120h |
| 105 | 2 | **NSF Tech Transfer** |  | 341d? | 2006-08-02 | 2007-11-21 |  | 88d |  |  |  | 2328h |
| 106 | 2.1 | Lab setup |  | 3d | 2006-08-02 | 2006-08-04 |  | 426d |  |  | EE_Tech | 24h |
| 107 | 2.2 | **Production** |  | 269d? | 2006-08-02 | 2007-08-13 |  | 109d |  |  |  | 1616h |
| 108 | 2.2.1 | **Mechanical** |  | 264d? | 2006-08-02 | 2007-08-06 |  | 109d |  |  |  | 1528h |
| 109 | 2.2.1.1 | All COTS parts in house | milestone | 0d | 2006-08-31 | 2006-08-31 |  | 407d |  | finish no earlier than 2006-08-31 | ME_Tech |  |
| 110 | 2.2.1.2 | All Fabricated parts in house | milestone | 0d | 2006-08-31 | 2006-08-31 |  | 88d | 0d | start no earlier than 2006-08-31 | ME_Tech |  |
| 111 | 2.2.1.3 | Waste container & brackets |  | 5d? | 2006-08-31 | 2006-09-06 | 110 | 88d | 0d |  | ME_Tech | 40h |
| 112 | 2.2.1.4 | Camera Jig |  | 3d? | 2006-08-02 | 2006-08-04 |  | 426d |  |  | ME_Tech | 24h |
| 113 | 2.2.1.5 | **Subassembly** |  | 136d | 2006-09-07 | 2007-03-15 |  | 88d |  |  |  | 648h |
| 114 | 2.2.1.5.1 | Carosel |  | 5d | 2006-09-07 | 2006-09-13 | 111 | 88d | 0d |  | Mechatronic | 40h |
| 115 | 2.2.1.5.2 | Carosel mounting/top plate |  | 3d | 2006-09-14 | 2006-09-18 | 114 | 88d | 0d |  | Mechatronic | 24h |
| 116 | 2.2.1.5.3 | Syringes |  | 4d | 2006-09-19 | 2006-09-22 | 115 | 88d | 0d |  | Mechatronic | 32h |
| 117 | 2.2.1.5.4 | Manipulator Mechanical |  | 5d | 2006-09-25 | 2006-09-29 | 116 | 88d | 0d |  | Mechatronic | 40h |
| 118 | 2.2.1.5.5 | Clamps |  | 5d | 2006-10-02 | 2006-10-06 | 117 | 88d | 0d |  | Mechatronic | 40h |
| 119 | 2.2.1.5.6 | Heater |  | 5d | 2006-10-09 | 2006-10-13 | 118 | 88d | 0d |  | Mechatronic | 40h |
| 120 | 2.2.1.5.7 | Plate |  | 5d | 2006-10-16 | 2006-10-20 | 119 | 88d | 0d |  | Mechatronic | 40h |
| 121 | 2.2.1.5.8 | Rotary Valves |  | 9d | 2006-10-23 | 2006-11-02 | 120 | 88d | 0d |  | Mechatronic | 72h |
| 122 | 2.2.1.5.9 | Syringe and rotary valve |  | 1d | 2006-11-03 | 2006-11-03 | 121 | 88d | 0d |  | Mechatronic | 8h |
| 123 | 2.2.1.5.10 | Series Valves |  | 3d | 2006-11-06 | 2006-11-08 | 122 | 88d | 0d |  | Mechatronic | 24h |
| 124 | 2.2.1.5.11 | Camera |  | 4d | 2006-11-09 | 2006-11-14 | 123 | 88d | 0d |  | Mechatronic | 32h |
| 125 | 2.2.1.5.12 | Camera power supply |  | 2d | 2006-11-15 | 2006-11-16 | 124 | 88d | 0d |  | Mechatronic | 16h |
| 126 | 2.2.1.5.13 | Elevator |  | 3d | 2006-11-17 | 2006-11-21 | 125 | 88d | 0d |  | Mechatronic | 24h |
| 127 | 2.2.1.5.14 | Dwarf assembly |  | 5d | 2006-11-22 | 2006-11-28 | 126 | 88d | 0d |  | Mechatronic | 40h |
| 128 | 2.2.1.5.15 | Sleepy board mounting |  | 2d | 2006-11-29 | 2006-11-30 | 127 | 88d | 0d |  | Mechatronic | 16h |
| 129 | 2.2.1.5.16 | Manipulator Final |  | 5d | 2006-12-01 | 2006-12-07 | 128 | 88d | 0d |  | Mechatronic | 40h |
| 130 | 2.2.1.5.17 | Tube preparation and plumbing |  | 9d | 2006-12-08 | 2006-12-20 | 129 | 88d | 0d |  | Mechatronic | 72h |
| 131 | 2.2.1.5.18 | Jensen spit tubes |  | 1d | 2006-12-21 | 2006-12-21 | 130 | 88d | 0d |  | Mechatronic | 8h |
| 132 | 2.2.1.5.19 | Miscellaneous |  | 60d | 2006-12-22 | 2007-03-15 | 131 | 88d | 0d |  | Mechatronic [8.3%] | 40h |
| 133 | 2.2.1.5.20 | Subassemblies complete | milestone | 0d | 2007-03-15 | 2007-03-15 | 132 | 88d | 0d |  | Mechatronic |  |

| ID | WBS | Task | Type | Duration | Start | Finish | Predecessors | Total slack | Free slack | Resources | Work |
| --- | --- | --- | --- | --- | --- | --- | --- | --- | --- | --- | --- |
| 134 | 2.2.1.6 | **Final Assembly** |  | 102d | 2007-03-16 | 2007-08-06 | 133 | 88d |  |  | 816h |
| 135 | 2.2.1.6.1 | Mounting plate on holder |  | 4d | 2007-03-16 | 2007-03-21 | 131 | 88d | 0d | Mechatronic | 32h |
| 136 | 2.2.1.6.2 | heaters |  | 2d | 2007-03-22 | 2007-03-23 | 135 | 88d | 0d | Mechatronic | 16h |
| 137 | 2.2.1.6.3 | Elevator |  | 2d | 2007-03-26 | 2007-03-27 | 136 | 88d | 0d | Mechatronic | 16h |
| 138 | 2.2.1.6.4 | Clamps |  | 1d | 2007-03-28 | 2007-03-28 | 137 | 88d | 0d | Mechatronic | 8h |
| 139 | 2.2.1.6.5 | Syringe and Rotary Valve |  | 1d | 2007-03-29 | 2007-03-29 | 138 | 88d | 0d | Mechatronic | 8h |
| 140 | 2.2.1.6.6 | Rotary valves |  | 4d | 2007-03-30 | 2007-04-04 | 139 | 88d | 0d | Mechatronic | 32h |
| 141 | 2.2.1.6.7 | Series valves |  | 1d | 2007-04-05 | 2007-04-05 | 140 | 88d | 0d | Mechatronic | 8h |
| 142 | 2.2.1.6.8 | Plumbing iniitial |  | 4d | 2007-04-06 | 2007-04-11 | 141 | 88d | 0d | Mechatronic | 32h |
| 143 | 2.2.1.6.9 | Camera |  | 1d | 2007-04-12 | 2007-04-12 | 142 | 88d | 0d | Mechatronic | 8h |
| 144 | 2.2.1.6.10 | Manipulator |  | 1d | 2007-04-13 | 2007-04-13 | 143 | 88d | 0d | Mechatronic | 8h |
| 145 | 2.2.1.6.11 | Garage |  | 1d | 2007-04-16 | 2007-04-16 | 144 | 88d | 0d | Mechatronic | 8h |
| 146 | 2.2.1.6.12 | Dwarfs |  | 4d | 2007-04-17 | 2007-04-20 | 145 | 88d | 0d | Mechatronic | 32h |
| 147 | 2.2.1.6.13 | Sleepy board |  | 1d | 2007-04-23 | 2007-04-23 | 146 | 88d | 0d | Mechatronic | 8h |
| 148 | 2.2.1.6.14 | Wiring |  | 8d | 2007-04-24 | 2007-05-03 | 147 | 88d | 0d | Mechatronic | 64h |
| 149 | 2.2.1.6.15 | Camera power supply |  | 2d | 2007-05-04 | 2007-05-07 | 148 | 88d | 0d | Mechatronic | 16h |
| 150 | 2.2.1.6.16 | Waste container |  | 1d | 2007-05-08 | 2007-05-08 | 149 | 88d | 0d | Mechatronic | 8h |
| 151 | 2.2.1.6.17 | Plumbing Final |  | 4d | 2007-05-09 | 2007-05-14 | 150 | 88d | 0d | Mechatronic | 32h |
| 152 | 2.2.1.6.18 | Miscellaneous |  | 60d | 2007-05-15 | 2007-08-06 | 151 | 88d | 0d | Mechatronic | 480h |
| 153 | 2.2.1.6.19 | Final assembly complete | milestone | 0d | 2007-08-06 | 2007-08-06 | 152 | 88d | 0d | Mechatronic |  |
| 154 | 2.2.2 | **Software** |  | 5d? | 2007-08-07 | 2007-08-13 |  | 160d |  |  | 40h |
| 155 | 2.2.2.1 | Finalized CDs? |  | 5d? | 2007-08-07 | 2007-08-13 | 153 | 160d |  | SE | 40h |
| 156 | 2.2.3 | **Electrical** |  | 6d? | 2006-09-07 | 2006-09-14 |  | 392d |  |  | 48h |
| 157 | 2.2.3.1 | Cabling |  | 2d? | 2006-09-07 | 2006-09-08 | 111 | 392d | 0d | EE | 16h |
| 158 | 2.2.3.2 | Fabrication |  | 2d? | 2006-09-11 | 2006-09-12 | 157 | 392d | 0d | EE_Tech | 16h |
| 159 | 2.2.3.3 | Existing board update |  | 2d? | 2006-09-13 | 2006-09-14 | 158 | 392d | 0d | EE_Tech | 16h |

| ID | WBS | Task | Type | Duration | Start | Finish | Predecessors | Complete | Remaining | Baseline start | Baseline finish | Baseline duration | Total slack | Free slack | Constraint | Resources | Work | Actual work |
| --- | --- | --- | --- | --- | --- | --- | --- | --- | --- | --- | --- | --- | --- | --- | --- | --- | --- | --- |
| 160 | 2.2.4 | **Readiness Review** |  | 5d? | 2006-09-15 | 2006-09-21 |  |  |  |  |  |  | 392d |  |  |  |  |  |
| 161 | 2.2.4.1 | Readiness Review Preparation |  | 4d | 2006-09-15 | 2006-09-20 | 159 |  |  |  |  |  | 392d | 0d |  |  |  |  |
| 162 | 2.2.4.2 | Readiness Review |  | 1d? | 2006-09-21 | 2006-09-21 | 161 |  |  |  |  |  | 392d |  |  |  |  |  |
| 163 | 2.3 | **Quality Assurance** |  | 46d | 2007-08-07 | 2007-10-09 |  |  |  |  |  |  | 88d |  |  |  | 336h |  |
| 164 | 2.3.1 | Alignment |  | 10d | 2007-08-07 | 2007-08-20 | 153 |  |  |  |  |  | 88d | 0d |  | Mechatronic | 80h |  |
| 165 | 2.3.2 | Reagent Storage |  | 5d | 2007-08-21 | 2007-08-27 | 164 |  |  |  |  |  | 88d | 0d |  |  | 8h |  |
| 166 | 2.3.3 | Initial Integration & Test |  | 10d | 2007-08-28 | 2007-09-10 | 165 |  |  |  |  |  | 88d | 0d |  | Team | 80h |  |
| 167 | 2.3.4 | Cold water test |  | 8d | 2007-09-11 | 2007-09-20 | 166 |  |  |  |  |  | 88d | 0d |  | Team | 64h |  |
| 168 | 2.3.5 | Tank test |  | 8d | 2007-09-21 | 2007-10-02 | 167 |  |  |  |  |  | 88d | 0d |  | Team | 64h |  |
| 169 | 2.3.6 | Rework |  | 5d | 2007-10-03 | 2007-10-09 | 168 |  |  |  |  |  | 88d | 0d |  | Team | 40h |  |
| 170 | 2.4 | **Support** |  | 59d | 2007-08-31 | 2007-11-21 |  |  |  |  |  |  | 88d |  |  |  | 352h |  |
| 171 | 2.4.1 | Copy Resources |  | 2d | 2007-10-10 | 2007-10-11 | 169 |  |  | 2006-01-04 | 2006-01-04 | 1d? | 88d | 0d |  |  |  |  |
| 172 | 2.4.2 | **Documentation** |  | 10d | 2007-10-12 | 2007-10-25 | 171 |  |  |  |  |  | 88d | 0d |  |  | 240h |  |
| 173 | 2.4.2.1 | Software user manual |  | 10d | 2007-10-12 | 2007-10-25 | 153 |  |  |  |  |  | 88d |  |  | SE | 80h |  |
| 174 | 2.4.2.2 | ME Manual |  | 10d | 2007-10-12 | 2007-10-25 | 153 |  |  |  |  |  | 88d |  |  | ME_Tech | 80h |  |
| 175 | 2.4.2.3 | EE Manual |  | 10d | 2007-10-12 | 2007-10-25 | 153 |  |  |  |  |  | 88d |  |  | EE_Tech | 80h |  |
| 176 | 2.4.3 | initial user workshop - prep for demo deployments in 07; joint proposals |  | 14d | 2007-10-26 | 2007-11-14 | 172 |  |  | 2006-01-04 | 2006-01-04 | 1d? | 88d | 0d |  | ME | 112h |  |
| 177 | 2.4.4 | workshop Resources |  | 5d | 2007-11-15 | 2007-11-21 | 176 |  |  | 2006-12-04 | 2006-12-04 | 1d? | 88d |  |  |  |  |  |
| 178 | 2.4.5 | Workshop | milestone | 0d | 2007-08-31 | 2007-08-31 |  |  |  |  |  |  | 147d |  | start no earlier than 2007-08-31 |  |  |  |
| 180 | 3 | **MBARI ESP Apps (Surface)** |  | 303d | 2006-08-02 A | 2007-09-28 |  | 1% | 299.16d |  |  |  | 126d |  |  |  | 7832h | 64h |
| 181 | 3.1 | **Rebuild** |  | 55d | 2006-08-02 A | 2006-10-17 |  | 14% | 47.41d |  |  |  | 374d |  |  |  | 144h | 64h |
| 182 | 3.1.1 | Rebuild Heaters |  | 8d | 2006-08-02 A | 2006-08-11 A |  | 100% |  |  |  |  |  |  |  | EE | 64h | 64h |
| 183 | 3.1.2 | Recalibrate |  | 2d | 2006-08-14 | 2006-08-15 | 182 |  |  |  |  |  | 419d |  |  | EE | 16h |  |
| 184 | 3.1.3 | Demoic Acid protocols |  | 2d | 2006-08-14 | 2006-08-15 | 182 |  |  |  |  |  | 189d | 0d |  |  |  |  |
| 185 | 3.1.4 | Test plan |  | 1d | 2006-08-16 | 2006-08-16 | 184 |  |  |  |  |  | 418d |  |  | EE | 8h |  |
| 186 | 3.1.5 | Demoic Acid laboratory runs |  | 3d | 2006-08-16 | 2006-08-18 | 184 |  |  |  |  |  | 189d | 0d |  |  |  |  |
| 187 | 3.1.6 | Demoic acid collaboration |  | 5d | 2006-08-21 | 2006-08-25 | 186 |  |  |  |  |  | 189d | 0d |  |  |  |  |
| 188 | 3.1.7 | Image Analysis Meeting | milestone | 0d | 2006-08-23 | 2006-08-23 | 186 |  |  |  |  |  | 414d |  | start no earlier than 2006-08-23 |  |  |  |
| 189 | 3.1.8 | Engineering tests |  | 2d | 2006-08-28 | 2006-08-29 | 187 |  |  |  |  |  | 189d | 0d |  | EE | 16h |  |
| 190 | 3.1.9 | C. Preston's runs |  | 3d | 2006-08-30 | 2006-09-01 | 189 |  |  |  |  |  | 189d | 0d |  |  |  |  |
| 191 | 3.1.10 | Lab tests |  | 15d | 2006-09-04 | 2006-09-22 | 190 |  |  |  |  |  | 189d | 0d |  |  |  |  |
| 192 | 3.1.11 | Cold tests |  | 5d | 2006-09-25 | 2006-09-29 | 191 |  |  |  |  |  | 189d | 0d |  | EE | 40h |  |
| 193 | 3.1.12 | Robust test results summary | milestone | 0d | 2006-09-29 | 2006-09-29 | 192 |  |  |  |  |  | 189d | 0d |  | EE |  |  |
| 194 | 3.1.13 | Prepare for surface deployment |  | 1d | 2006-10-02 | 2006-10-02 | 193 |  |  |  |  |  | 374d | 0d |  |  |  |  |
| 195 | 3.1.14 | Surface deployment |  | 1d | 2006-10-03 | 2006-10-03 | 194 |  |  |  |  |  | 374d | 0d |  |  |  |  |
| 196 | 3.1.15 | Surface mission |  | 10d | 2006-10-04 | 2006-10-17 | 195 |  |  |  |  |  | 374d | 0d |  |  |  |  |
| 197 | 3.1.16 | Surface recovery | milestone | 0d | 2006-10-17 | 2006-10-17 | 196 |  |  |  |  |  | 374d |  |  |  |  |  |

| ID | WBS | Task | Type | Duration | Start | Finish | Predecessors | Total slack | Free slack | Constraint | Resources | Work |
| --- | --- | --- | --- | --- | --- | --- | --- | --- | --- | --- | --- | --- |
| 198 | 3.2 | **Replace Bulkhead valves** |  | 72d | 2006-10-02 | 2007-01-09 | 193 | 189d |  |  |  | 576h |
| 199 | 3.2.1 | Design specifications |  | 7d | 2006-10-02 | 2006-10-10 |  | 189d | 0d |  | Team | 56h |
| 200 | 3.2.2 | ME design |  | 7d | 2006-10-11 | 2006-10-19 | 199 | 189d | 0d |  | ME_Tech | 56h |
| 201 | 3.2.3 | EE Design |  | 7d | 2006-10-20 | 2006-10-30 | 200 | 189d | 0d |  | EE | 56h |
| 202 | 3.2.4 | Procurement |  | 21d | 2006-10-31 | 2006-11-28 | 201 | 189d | 0d |  | EE_Tech | 168h |
| 203 | 3.2.5 | EE fab. |  | 10d | 2006-11-29 | 2006-12-12 | 202 | 189d | 0d |  | EE_Tech | 80h |
| 204 | 3.2.6 | ME Fab. |  | 10d | 2006-12-13 | 2006-12-26 | 203 | 189d | 0d |  | ME_Tech | 80h |
| 205 | 3.2.7 | Testing |  | 10d | 2006-12-27 | 2007-01-09 | 204 | 189d | 0d |  | Team | 80h |
| 206 | 3.3 | **Puck Development (13mm)** |  | 115d | 2007-01-10 | 2007-06-19 | 193 | 189d |  |  |  | 1000h |
| 207 | 3.3.1 | Determine specifications |  | 10d | 2007-01-10 | 2007-01-23 | 205 | 189d | 0d |  | ME; Roman | 160h |
| 208 | 3.3.2 | Drawings |  | 5d | 2007-01-24 | 2007-01-30 | 207 | 189d | 0d |  | ME | 40h |
| 209 | 3.3.3 | Procure |  | 90d | 2007-01-31 | 2007-06-05 | 208 | 189d | 0d |  | ME_Tech | 720h |
| 210 | 3.3.4 | Test |  | 10d | 2007-06-06 | 2007-06-19 | 209 | 189d | 0d |  | ME_Tech | 80h |
| 211 | 3.3.5 | Pucks accepted | milestone | 0d | 2007-06-19 | 2007-06-19 | 210 | 189d | 0d |  | Team |  |
| 212 | 3.4 | **New Control** |  | 194d | 2007-01-02 | 2007-09-28 |  | 126d |  |  |  | 6112h |
| 213 | 3.4.1 | Multi-threaded s/w protocols |  | 10d | 2007-06-20 | 2007-07-03 | 211 | 189d | 0d |  | SE | 80h |
| 214 | 3.4.2 | **GUI s/w control & monitoring** |  | 183d | 2007-01-02 | 2007-09-13 |  | 137d |  |  | SE | 2928h |
| 215 | 3.4.2.1 | Initial design of GUI framework |  | 60d | 2007-01-02 | 2007-03-26 |  | 190d | 0d | start no earlier than 2007-01-02 | SE | 480h |
| 216 | 3.4.2.2 | PDR Preparation |  | 5d | 2007-03-27 | 2007-04-02 | 215 | 190d | 0d |  | SE | 40h |
| 217 | 3.4.2.3 | PDR | milestone | 0d | 2007-04-02 | 2007-04-02 | 216 | 190d | 0d |  | SE |  |
| 218 | 3.4.2.4 | control LLNL block |  | 72d | 2007-04-03 | 2007-07-11 | 217 | 137d | 0d | start no earlier than 2007-01-08 | SE | 576h |
| 219 | 3.4.2.5 | Prepare for CDR |  | 5d | 2007-07-12 | 2007-07-18 | 218 | 137d | 0d |  | SE | 40h |
| 220 | 3.4.2.6 | CDR | milestone | 0d | 2007-07-18 | 2007-07-18 | 219 | 137d | 0d |  | SE |  |
| 221 | 3.4.2.7 | state monitoring of core |  | 41d | 2007-07-19 | 2007-09-13 | 220 | 137d | 0d |  | SE | 328h |
| 222 | 3.4.2.8 | Readiness Review | milestone | 0d | 2007-09-13 | 2007-09-13 | 221 | 137d |  |  | SE |  |

| ID | WBS | Task | Type | Duration | Start | Finish | Predecessors | Total slack | Free slack | Constraint | Resources | Work |
| --- | --- | --- | --- | --- | --- | --- | --- | --- | --- | --- | --- | --- |
| 223 | 3.4.3 | **Data system with database** |  | 194d | 2007-01-02 | 2007-09-28 |  | 126d |  |  | SE | 3104h |
| 224 | 3.4.3.1 | Initial Design |  | 62d | 2007-01-02 | 2007-03-28 |  | 137d | 0d | start no earlier than 2007-01-02 | SE | 496h |
| 225 | 3.4.3.2 | Prepare for PDR |  | 5d | 2007-03-29 | 2007-04-04 | 224 | 137d | 0d |  | SE | 40h |
| 226 | 3.4.3.3 | PDR | milestone | 0d | 2007-04-04 | 2007-04-04 | 225 | 137d | 0d |  | SE |  |
| 227 | 3.4.3.4 | Develop first cut |  | 64d | 2007-04-05 | 2007-07-03 | 226 | 137d | 0d |  | SE | 512h |
| 228 | 3.4.3.5 | Prepare for CDR |  | 5d | 2007-07-04 | 2007-07-10 | 227 | 137d | 0d |  | SE | 40h |
| 229 | 3.4.3.6 | CDR | milestone | 0d | 2007-07-10 | 2007-07-10 | 228 | 137d | 0d |  | SE |  |
| 230 | 3.4.3.7 | Finish development |  | 58d | 2007-07-11 | 2007-09-28 | 229 | 126d | 0d |  | SE | 464h |
| 231 | 3.4.3.8 | Readiness Review | milestone | 0d | 2007-09-28 | 2007-09-28 | 230 | 126d |  |  | SE |  |
| 232 | 3.5 | **Deployments** |  | 26d | 2007-05-29 | 2007-07-03 |  | 189d |  |  |  |  |
| 233 | 3.5.1 | Surface 1 | milestone | 0d | 2007-07-03 | 2007-07-03 | 213 | 189d |  | start no earlier than 2007-05-15 | Team |  |
| 234 | 3.5.2 | Surface 2 | milestone | 0d | 2007-05-29 | 2007-05-29 |  | 215d |  | start no earlier than 2007-05-29 | Team |  |
| 235 | 4 | **Moore (Walt Array)** |  | 394d | 2006-09-20 | 2008-03-24 |  | 0d |  |  |  | 5072h |
| 236 | 4.1 | **Walt Specs** |  | 89d | 2006-09-20 | 2007-01-22 |  | 0d |  |  |  | 712h |
| 237 | 4.1.1 | visit Tufts | milestone | 0d | 2006-09-20 | 2006-09-20 |  | 0d |  | start no earlier than 2006-09-20 | Team |  |
| 238 | 4.1.2 | Develop ICD |  | 40d | 2006-09-20 | 2006-11-14 | 237 | 0d |  |  | Kevin | 320h |
| 239 | 4.1.3 | Initial design |  | 40d | 2006-11-15 | 2007-01-09 | 238 | 0d |  |  | Team | 320h |
| 240 | 4.1.4 | PDR Preparation |  | 9d | 2007-01-10 | 2007-01-22 | 239 | 0d |  |  | Team | 72h |
| 241 | 4.1.5 | PDR | milestone | 0d | 2007-01-22 | 2007-01-22 | 240 | 0d |  |  | Team |  |
| 242 | 4.2 | **Walt benchtop design** |  | 104d | 2007-01-10 | 2007-06-04 | 239 | 9d |  |  |  | 1720h |
| 243 | 4.2.1 | Optical design |  | 60d | 2007-01-23 | 2007-04-16 | 241 | 0d |  |  | ME | 480h |
| 244 | 4.2.2 | Electrical design |  | 60d | 2007-01-10 | 2007-04-03 | 239 | 254d |  |  | EE | 480h |
| 245 | 4.2.3 | Software design |  | 60d | 2007-01-10 | 2007-04-03 | 239 | 254d |  |  | SE | 480h |
| 246 | 4.2.4 | Mechanical design |  | 30d | 2007-04-17 | 2007-05-28 | 243 | 0d |  |  | ME | 240h |
| 247 | 4.2.5 | CDR Preparation |  | 5d | 2007-05-29 | 2007-06-04 | 246 | 0d |  |  | Team | 40h |
| 248 | 4.2.6 | CDR | milestone | 0d | 2007-06-04 | 2007-06-04 | 247 | 0d |  |  | Team |  |

| ID | WBS | Task | Type | Duration | Start | Finish | Predecessors | Total slack | Free slack | Constraint | Resources | Work |
| --- | --- | --- | --- | --- | --- | --- | --- | --- | --- | --- | --- | --- |
| 249 | 4.3 | **Walt benchtop dev.** |  | 210d | 2007-06-05 | 2008-03-24 |  | 0d |  |  |  | 2640h |
| 250 | 4.3.1 | Optical procurement |  | 60d | 2007-06-05 | 2007-08-27 | 248 | 0d |  |  | EE_Tech | 480h |
| 251 | 4.3.2 | Electrical procurement |  | 30d | 2007-06-05 | 2007-07-16 | 248 | 150d | 0d |  | EE_Tech | 240h |
| 252 | 4.3.3 | Mechanical procurement |  | 30d | 2007-06-05 | 2007-07-16 | 248 | 150d | 0d |  | ME_Tech | 240h |
| 253 | 4.3.4 | Optical assembly & testing |  | 60d | 2007-08-28 | 2007-11-19 | 250 | 0d |  |  | EE | 480h |
| 254 | 4.3.5 | Electrical fab. |  | 30d | 2007-07-17 | 2007-08-27 | 251 | 150d |  |  | EE_Tech | 240h |
| 255 | 4.3.6 | Mechanical fab. |  | 30d | 2007-07-17 | 2007-08-27 | 252 | 150d |  |  | ME_Tech | 240h |
| 256 | 4.3.7 | Software development |  | 60d | 2007-11-20 | 2008-02-11 | 253 | 0d |  |  | SE | 480h |
| 257 | 4.3.8 | Testing |  | 30d | 2008-02-12 | 2008-03-24 | 256 | 0d |  |  | SE | 240h |
| 260 | 5 | **C-MORE** |  | 221d | 2006-11-06 | 2007-09-10 |  | 140d |  |  |  | 2848h |
| 261 | 5.1 | **cmore scoping** |  | 184d | 2006-11-06 | 2007-07-19 |  | 140d |  |  |  | 1832h |
| 262 | 5.1.1 | Hawaii trip |  | 7d | 2006-11-06 | 2006-11-14 |  | 140d | 0d | start no earlier than 2006-11-06 | Kevin | 56h |
| 263 | 5.1.2 | Initial specifications |  | 30d | 2006-11-15 | 2006-12-26 | 262 | 140d | 0d |  | Kevin | 240h |
| 264 | 5.1.3 | Market survey |  | 21d | 2006-12-27 | 2007-01-24 | 263 | 140d | 0d |  | EE_Tech | 168h |
| 265 | 5.1.4 | Initial procurement |  | 30d | 2007-01-25 | 2007-03-07 | 264 | 140d | 0d |  | EE_Tech | 240h |
| 266 | 5.1.5 | Initial electronics |  | 45d | 2007-03-08 | 2007-05-09 | 265 | 228d |  |  | EE | 360h |
| 267 | 5.1.6 | Initial s/w |  | 45d | 2007-03-08 | 2007-05-09 | 265 | 140d | 0d |  | SE | 360h |
| 268 | 5.1.7 | Assembly of pieces |  | 21d | 2007-05-10 | 2007-06-07 | 267 | 140d | 0d |  | EE_Tech | 168h |
| 269 | 5.1.8 | Initial tests |  | 30d | 2007-06-08 | 2007-07-19 | 268 | 140d | 0d |  | EE | 240h |
| 270 | 5.2 | **cmore prototype** |  | 37d | 2007-07-20 | 2007-09-10 |  | 140d |  |  |  | 1016h |
| 271 | 5.2.1 | ME design |  | 30d | 2007-07-20 | 2007-08-30 | 269 | 147d |  |  | ME_Tech | 240h |
| 272 | 5.2.2 | EE Design |  | 30d | 2007-07-20 | 2007-08-30 | 269 | 147d |  |  | EE | 240h |
| 273 | 5.2.3 | Optical Design |  | 30d | 2007-07-20 | 2007-08-30 | 269 | 140d | 0d |  | ME | 240h |
| 274 | 5.2.4 | S/W design |  | 30d | 2007-07-20 | 2007-08-30 | 269 | 147d |  |  | SE | 240h |
| 275 | 5.2.5 | Prepare for PDR |  | 7d | 2007-08-31 | 2007-09-10 | 273 | 140d | 0d |  | Team | 56h |
| 276 | 5.2.6 | PDR | milestone | 0d | 2007-09-10 | 2007-09-10 | 275 | 140d |  |  | Team |  |
