# ESPsupport

Schedule from MS Project, 2007-03-05 to 2007-12-28.
MBARI

## Calendars

- Standard: Mon-Fri 08:00-12:00, 13:00-17:00; Sat-Sun off.

## Resources

| Resource |
| --- |
| ME_Tech |
| EE_Tech |

## Schedule

| ID | WBS | Task | Duration | Start | Finish | Predecessors | Total slack | Free slack | Constraint |
| --- | --- | --- | --- | --- | --- | --- | --- | --- | --- |
| 2 | 1 | 4k DWSM Parts Fabrication (703506) | 80d? | 2007-09-10 | 2007-12-28 |  | 0d |  | finish no earlier than 2007-12-28 |
| 3 | 2 | Sniffer Wand Fab/Test (703506) | 15d | 2007-04-27 | 2007-05-17 |  | 161d |  | start no earlier than 2007-04-27 |
| 4 | 3 | Deep ISUS Housing Fabrication/Test (703506) | 15d | 2007-04-26 | 2007-05-16 |  | 162d |  | start no earlier than 2007-04-26 |
| 5 | 4 | Fab/Assemble 2nd surface mooring (900612) | 30d | 2007-06-18 | 2007-07-27 |  | 110d |  | start no earlier than 2007-06-18 |
| 6 | 5 | Tech Transfer units build (900612) | 100d | 2007-03-05 | 2007-07-20 |  | 115d |  | start no earlier than 2007-03-05 |
| 7 | 6 | Micro-FB Parts Fabrication (800560) | 15d | 2007-04-04 | 2007-04-24 |  | 158d | 0d | start no earlier than 2007-04-04 |
| 8 | 7 | Micro-FB Electrical assembly (800560) | 20d | 2007-04-25 | 2007-05-22 | 7 | 158d |  |  |
| 9 | 8 | Snap Puck Prototyping | 10d | 2007-03-20 | 2007-04-02 |  | 139d | 0d |  |
| 10 | 9 | Snap Puck Pre-Production | 15d | 2007-04-03 | 2007-04-23 | 9 | 139d | 0d |  |
| 11 | 10 | Snap Puck Production (703506) | 40d | 2007-04-24 | 2007-06-18 | 10 | 139d |  |  |
