# Moore

Schedule from MS Project, 2006-09-20 to 2008-03-24.
MBARI

## Calendars

- Standard: Mon-Fri 08:00-12:00, 13:00-17:00; Sat-Sun off.

## Resources

| Resource |
| --- |
| Software |
| SE |
| ME |
| ME_Tech |
| Team |
| EE |
| EE_Tech |
| Scott |
| Gene |
| Mark Brown |
| Brent |
| Roman |
| Kevin |
| Kevni |
| Conway |
| Mechatronic |
| Science |

## Schedule

| ID | WBS | Task | Type | Duration | Start | Finish | Predecessors | Total slack | Free slack | Constraint | Resources | Work |
| --- | --- | --- | --- | --- | --- | --- | --- | --- | --- | --- | --- | --- |
| 3 | 1 | **Moore (Walt Array)** |  | 394d | 2006-09-20 | 2008-03-24 |  | 0d |  |  |  | 5072h |
| 4 | 1.1 | **Walt Specs** |  | 89d | 2006-09-20 | 2007-01-22 |  | 0d |  |  |  | 712h |
| 5 | 1.1.1 | visit Tufts | milestone | 0d | 2006-09-20 | 2006-09-20 |  | 0d |  | start no earlier than 2006-09-20 | Team |  |
| 6 | 1.1.2 | Develop ICD |  | 40d | 2006-09-20 | 2006-11-14 | 5 | 0d |  |  | Kevin | 320h |
| 7 | 1.1.3 | Initial design |  | 40d | 2006-11-15 | 2007-01-09 | 6 | 0d |  |  | Team | 320h |
| 8 | 1.1.4 | PDR Preparation |  | 9d | 2007-01-10 | 2007-01-22 | 7 | 0d |  |  | Team | 72h |
| 9 | 1.1.5 | PDR | milestone | 0d | 2007-01-22 | 2007-01-22 | 8 | 0d |  |  | Team |  |
| 10 | 1.2 | **Walt benchtop design** |  | 104d | 2007-01-10 | 2007-06-04 | 7 | 9d |  |  |  | 1720h |
| 11 | 1.2.1 | Optical design |  | 60d | 2007-01-23 | 2007-04-16 | 9 | 0d |  |  | ME | 480h |
| 12 | 1.2.2 | Electrical design |  | 60d | 2007-01-10 | 2007-04-03 | 7 | 254d |  |  | EE | 480h |
| 13 | 1.2.3 | Software design |  | 60d | 2007-01-10 | 2007-04-03 | 7 | 254d |  |  | SE | 480h |
| 14 | 1.2.4 | Mechanical design |  | 30d | 2007-04-17 | 2007-05-28 | 11 | 0d |  |  | ME | 240h |
| 15 | 1.2.5 | CDR Preparation |  | 5d | 2007-05-29 | 2007-06-04 | 14 | 0d |  |  | Team | 40h |
| 16 | 1.2.6 | CDR | milestone | 0d | 2007-06-04 | 2007-06-04 | 15 | 0d |  |  | Team |  |
| 17 | 1.3 | **Walt benchtop dev.** |  | 210d | 2007-06-05 | 2008-03-24 |  | 0d |  |  |  | 2640h |
| 18 | 1.3.1 | Optical procurement |  | 60d | 2007-06-05 | 2007-08-27 | 16 | 0d |  |  | EE_Tech | 480h |
| 19 | 1.3.2 | Electrical procurement |  | 30d | 2007-06-05 | 2007-07-16 | 16 | 150d | 0d |  | EE_Tech | 240h |
| 20 | 1.3.3 | Mechanical procurement |  | 30d | 2007-06-05 | 2007-07-16 | 16 | 150d | 0d |  | ME_Tech | 240h |
| 21 | 1.3.4 | Optical assembly & testing |  | 60d | 2007-08-28 | 2007-11-19 | 18 | 0d |  |  | EE | 480h |
| 22 | 1.3.5 | Electrical fab. |  | 30d | 2007-07-17 | 2007-08-27 | 19 | 150d |  |  | EE_Tech | 240h |
| 23 | 1.3.6 | Mechanical fab. |  | 30d | 2007-07-17 | 2007-08-27 | 20 | 150d |  |  | ME_Tech | 240h |
| 24 | 1.3.7 | Software development |  | 60d | 2007-11-20 | 2008-02-11 | 21 | 0d |  |  | SE | 480h |
| 25 | 1.3.8 | Testing |  | 30d | 2008-02-12 | 2008-03-24 | 24 | 0d |  |  | SE | 240h |
