# Tech Transfer

Schedule from MS Project, 2006-12-04 to 2007-10-05, A marks actual dates.
MBARI

## Calendars

- Standard: Mon-Fri 08:00-12:00, 13:00-17:00; Sat-Sun off.

## Resources

| Resource |
| --- |
| Readiness Review |

## Schedule

| ID | WBS | Task | Type | Duration | Start | Finish | Predecessors | Complete | Remaining | Total slack | Free slack | Constraint |
| --- | --- | --- | --- | --- | --- | --- | --- | --- | --- | --- | --- | --- |
| 1 | 1 | Ready for PCR Integr | milestone | 0d | 2007-06-15 | 2007-06-15 | 8 |  |  | 80d |  | start no earlier than 2007-06-15 |
| 2 | 2 | Networked Deployment | milestone | 0d | 2007-08-30 | 2007-08-30 |  |  |  | 27d | 0d | start no earlier than 2007-08-30 |
| 3 | 3 | ESP Workshop |  | 5d | 2007-10-01 | 2007-10-05 |  |  |  | 0d |  | start no earlier than 2007-10-01 |
| 4 | 4 | **Technology Transfer** |  | 183d | 2006-12-04 A | 2007-08-16 |  | 9% | 165.84d | 37d |  |  |
| 5 | 4.1 | A1 Build Up |  | 60d | 2006-12-04 A | 2007-02-23 |  | 75% | 15d | 60d | 0d | start no earlier than 2006-12-04 |
| 6 | 4.2 | A1 Built | milestone | 0d | 2007-02-23 | 2007-02-23 | 5 |  |  | 60d | 0d |  |
| 7 | 4.3 | A1 Engr Test-Out |  | 60d | 2007-02-26 | 2007-05-18 | 6 |  |  | 60d | 0d |  |
| 8 | 4.4 | A1 Validation |  | 20d | 2007-05-21 | 2007-06-15 | 7 |  |  | 80d | 0d |  |
| 9 | 4.5 | **+3 Build Up** |  | 100d | 2007-01-01 | 2007-05-18 |  |  |  | 60d | 19d |  |
| 10 | 4.5.1 | TT1 Build |  | 100d | 2007-01-01 | 2007-05-18 |  |  |  | 60d |  | start no earlier than 2007-01-01 |
| 11 | 4.5.2 | TT2 Build |  | 100d | 2007-01-01 | 2007-05-18 |  |  |  | 60d |  | start no earlier than 2007-01-01 |
| 12 | 4.5.3 | TT3 Build |  | 100d | 2007-01-01 | 2007-05-18 |  |  |  | 60d |  | start no earlier than 2007-01-01 |
| 13 | 4.6 | +3 Built | milestone | 0d | 2007-06-15 | 2007-06-15 | 9 |  |  | 41d | 0d | start no earlier than 2007-06-15 |
| 14 | 4.7 | +3 Engr Test-Out |  | 20d | 2007-06-15 | 2007-07-12 | 7, 13 |  |  | 41d | 0d |  |
| 15 | 4.8 | +3 Validation |  | 20d | 2007-07-13 | 2007-08-09 | 14 |  |  | 41d | 4d |  |
| 16 | 4.9 | Readiness Review | milestone | 0d | 2007-08-16 | 2007-08-16 | 2SF-10d, 15 |  |  | 37d |  | start no earlier than 2007-08-15 |
