# summary2007_v2

Schedule from MS Project, 2007-01-02 to 2007-12-28.
MBARI

## Calendars

- Standard: Mon-Fri 08:00-12:00, 13:00-17:00; Sat-Sun off.

## Resources

| Resource |
| --- |
| Readiness Review |

## Schedule

| ID | WBS | Task | Type | Duration | Start | Finish | Predecessors | Total slack | Free slack | Constraint |
| --- | --- | --- | --- | --- | --- | --- | --- | --- | --- | --- |
| 1 | 1 | **D-ESP ASTEP** |  | 193d | 2007-01-02 | 2007-09-27 |  | 257d |  |  |
| 2 | 1.1 | Deep water sample 1K profile |  | 42d | 2007-01-02 | 2007-02-28 |  | 274d | 0d | finish no earlier than 2007-02-28 |
| 3 | 1.2 | ROV Ventana profiling with DWSM | milestone | 0d | 2007-02-07 | 2007-02-07 |  | 424d |  | start no earlier than 2007-02-07 |
| 4 | 1.3 | ROV Ventana profiling with DWSM | milestone | 0d | 2007-02-28 | 2007-02-28 | 2 | 274d | 0d |  |
| 5 | 1.4 | CDR Preparation |  | 5d | 2007-03-01 | 2007-03-07 | 4 | 274d | 17d |  |
| 6 | 1.5 | CDR for LLNL's PCR unit | milestone | 0d | 2007-03-30 | 2007-03-30 | 5 | 257d | 0d | finish no earlier than 2007-03-30 |
| 7 | 1.6 | Prepare for readiness review |  | 20d | 2007-04-02 | 2007-04-27 | 6 | 257d | 0d |  |
| 8 | 1.7 | Readiness review for 3K sampler | milestone | 0d | 2007-04-27 | 2007-04-27 | 7 | 257d | 0d | finish no earlier than 2007-04-27 |
| 9 | 1.8 | Micro-fluidic benchtop unit |  | 109d | 2007-04-30 | 2007-09-27 | 8 | 257d |  |  |
| 10 | 2 | **Moore** |  | 259d | 2007-01-02 | 2007-12-28 |  | 0d |  |  |
| 11 | 2.1 | Dev. & Preparation for PDR |  | 42d | 2007-01-02 | 2007-02-28 |  | 0d |  | finish no earlier than 2007-02-28 |
| 12 | 2.2 | PDR for fluidic system | milestone | 0d | 2007-02-28 | 2007-02-28 | 11 | 0d |  |  |
| 13 | 2.3 | Dev. & Preparation for CDR |  | 84d | 2007-03-01 | 2007-06-26 | 12 | 0d |  |  |
| 14 | 2.4 | CDR | milestone | 0d | 2007-06-26 | 2007-06-26 | 13 | 0d |  |  |
| 15 | 2.5 | First tests with Walt Array |  | 133d | 2007-06-27 | 2007-12-28 | 14 | 0d |  |  |
| 16 | 3 | **C-MORE** |  | 253d | 2007-01-02 | 2007-12-20 |  | 197d |  |  |
| 17 | 3.1 | Functional Requirements Gathering |  | 151d | 2007-01-02 | 2007-07-31 |  | 197d | 0d | finish no earlier than 2007-07-31 |
| 18 | 3.2 | Functional Requirements Document | milestone | 0d | 2007-07-31 | 2007-07-31 | 17 | 197d | 0d |  |
| 19 | 3.3 | Usage scenarios & specifications |  | 102d | 2007-08-01 | 2007-12-20 | 18 | 197d | 0d |  |
| 20 | 3.4 | Specification Document | milestone | 0d | 2007-12-20 | 2007-12-20 | 19 | 197d |  |  |
| 21 | 4 | **ESP Applications** |  | 259d | 2007-01-02 | 2007-12-28 |  | 0d |  |  |
| 22 | 4.1 | Preparation for surface deployments |  | 85d | 2007-01-02 | 2007-04-30 |  | 255d | 3d | finish no earlier than 2007-04-30 |
| 23 | 4.2 | Two surface deployments |  | 20d | 2007-05-04 | 2007-05-31 | 22 | 252d | 0d | finish no earlier than 2007-05-31 |
| 24 | 4.3 | Dev. For networked deployment |  | 90d | 2007-06-01 | 2007-10-04 | 23 | 252d | 0d |  |
| 25 | 4.4 | Surface deployment (networked) | milestone | 0d | 2007-10-04 | 2007-10-04 | 24 | 252d |  | finish no earlier than 2006-10-31 |

| ID | WBS | Task | Type | Duration | Start | Finish | Predecessors | Total slack | Free slack | Constraint |
| --- | --- | --- | --- | --- | --- | --- | --- | --- | --- | --- |
| 26 | 4.5 | **Software GUI control & monitoring** |  | 182d | 2007-01-02 | 2007-09-12 |  | 268d |  |  |
| 27 | 4.5.1 | Initial design |  | 70d | 2007-01-02 | 2007-04-09 |  | 268d | 0d | start no earlier than 2007-01-02 |
| 28 | 4.5.2 | PDR | milestone | 0d | 2007-04-09 | 2007-04-09 | 27 | 268d | 0d |  |
| 29 | 4.5.3 | Dev. |  | 66d | 2007-04-10 | 2007-07-10 | 28 | 268d | 0d |  |
| 30 | 4.5.4 | CDR | milestone | 0d | 2007-07-10 | 2007-07-10 | 29 | 268d | 0d |  |
| 31 | 4.5.5 | Dev. |  | 46d | 2007-07-11 | 2007-09-12 | 30 | 268d | 0d |  |
| 32 | 4.5.6 | Readiness Review | milestone | 0d | 2007-09-12 | 2007-09-12 | 31 | 268d |  |  |
| 33 | 4.6 | **Database data archival system** |  | 191d | 2007-01-02 | 2007-09-25 |  | 8d |  |  |
| 34 | 4.6.1 | Initial Design |  | 70d | 2007-01-02 | 2007-04-09 |  | 8d | 0d | start no earlier than 2007-01-02 |
| 35 | 4.6.2 | PDR | milestone | 0d | 2007-04-09 | 2007-04-09 | 34 | 8d | 0d |  |
| 36 | 4.6.3 | Dev. |  | 70d | 2007-04-10 | 2007-07-16 | 35 | 8d | 0d |  |
| 37 | 4.6.4 | CDR | milestone | 0d | 2007-07-16 | 2007-07-16 | 36 | 8d | 0d |  |
| 38 | 4.6.5 | Dev. |  | 51d | 2007-07-17 | 2007-09-25 | 37 | 8d | 0d |  |
| 39 | 4.6.6 | Readiness Review | milestone | 0d | 2007-09-25 | 2007-09-25 | 38 | 8d |  |  |
| 40 | 4.7 | Puck Development |  | 60d | 2007-10-08 | 2007-12-28 | 39 | 0d |  | finish no earlier than 2007-12-28 |
| 41 | 5 | **Technology Transfer** |  | 197d | 2007-01-02 | 2007-10-03 |  | 253d |  |  |
| 42 | 5.1 | Transfer units build up |  | 193d | 2007-01-02 | 2007-09-27 |  | 254d | 1d | finish no earlier than 2007-09-27 |
| 43 | 5.2 | Readiness Review | milestone | 0d | 2007-09-28 | 2007-09-28 | 42 | 253d | 0d | finish no earlier than 2007-09-28 |
| 44 | 5.3 | Workshop |  | 3d | 2007-10-01 | 2007-10-03 | 43 | 253d |  |  |
